# 3GPP_Release-2000

Schedule from MS Project, 2000-01-03 to 2008-12-31, A marks actual dates.

## Calendars

- Standard: Mon-Fri 08:00-12:00, 13:00-17:00; Sat-Sun off.

## Resources

| Resource |
| --- |
| NP |
| N1 |
| N2 |
| N3 |
| N4 |
| N5 |
| TP |
| T1 |
| T2 |
| T3 |
| RP |
| R1 |
| R2 |
| R3 |
| R4 |
| SP |
| S1 |
| S2 |
| S3 |
| S4 |
| S5 |
| PCG |
| GP |
| No |
| CN4 |
| ? |
| WG G2 |
| G2 |
| G1 |
| G4 |
| G3 |
| All |
| Generic |
| MLST |
| G5 |
| S3; G2 |
| WG T2 |
| GP,G1 |
| G4,G5 |
| OMA |
| GP-G2 |
| Yes |
| GP; |
| N4; |
| GP; N1 |
| CT5 |
| C1 |
| R5 |
| Rel-7 |

## Schedule

| ID | WBS | Task | Duration | Start | Finish | Complete | Remaining | Baseline start | Baseline finish | Baseline duration | Total slack | Constraint | Deadline | Resources | Work | Actual work | Text9 | Text1 | Text6 | Text10 | Text8 | Text7 | Text4 | Text5 | Text11 |
| --- | --- | --- | --- | --- | --- | --- | --- | --- | --- | --- | --- | --- | --- | --- | --- | --- | --- | --- | --- | --- | --- | --- | --- | --- | --- |
| 1 | 1 | TESTING WP - VERSION 2006 June 14th | 1d | 2005-12-16 | 2005-12-16 |  |  | 2000-01-03 | 2000-01-03 | 1d | 793d | start no earlier than 2005-12-16 |  |  |  |  | 2044 |  |  |  |  |  |  |  |  |
| 2 | 2 | "CTRL + a" to display all the 3GPP fields | 1d | 2000-01-03 | 2000-01-03 |  |  | 2000-01-03 | 2000-01-03 | 1d | 2347d |  |  |  |  |  | 1462 |  |  |  |  |  |  |  |  |
| 3 | 3 | RAN5 (Conformance Testing) WIs, all Releases | 1d | 2005-12-16 | 2005-12-16 |  |  | 2000-01-03 | 2000-01-03 | 1d | 793d | start no earlier than 2005-12-16 |  |  |  |  | 2058 |  |  |  |  |  |  |  |  |
| 4 | 4 | Linked Wis only for information - progress depending on non testing activities not tracked | 1d | 2005-12-16 | 2005-12-16 |  |  | 2000-01-03 | 2000-01-03 | 1d | 793d | start no earlier than 2005-12-16 |  |  |  |  | 2058 |  |  |  |  |  |  |  |  |
| 5 | 5 | colours red-bold: Active WIs, black-bold:Closed, black-normal: Linked non RAN5 WIs | 1d | 2000-01-03 | 2000-01-03 |  |  | 2000-01-03 | 2000-01-03 | 1d | 2347d |  |  |  |  |  |  |  |  |  |  |  |  |  |  |
| 8 | 6 | **Small Technical Enhancements and Improvements for Rel99** | 2348d? | 2000-01-03 A | 2008-12-31 | 70% | 704.4d? |  |  |  | 0d |  |  | Generic | 9975.2h | 7548.8h |  | TEI | R99 | 03/01/00 |  |  |  |  |  |
| 9 | 6.1 | Small Technical Enhancements and Improvements for Rel 99 Conformance Testing | 674d? | 2000-01-03 A | 2008-12-31 | 70% | 202.2d? |  |  |  | 0d | finish no earlier than 2008-12-31 |  | R5 | 5392h | 3774.4h |  | TEI_Test | R99 |  | Stoyan Baev |  |  |  |  |
| 10 | 8 | **Rel-6 Improvements of Radio Interface** | 650d | 2003-09-19 A | 2006-03-16 | 99% | 0d | 2000-08-14 | 2005-06-15 | 1262d? | 0d |  |  | RP | 29136h | 22124h |  | RInImp | Rel-6 |  | Cesar | TSG |  |  |  |
| 11 | 7.1 | **Improved Receiver Performance Requirements for HSDPA** | 650d | 2003-09-19 A | 2006-03-16 | 99% | 0d | 2003-12-15 | 2005-06-15 | 392d? | 0d |  |  | R4 | 26000h | 18988h |  | RInImp-HSPerf | Rel-6 |  | MCC RAN | TSG | Jussi Numminen, Nokia | jussi.numminen@NOKIA.COM |  |
| 12 | 7.1.1 | **Improved Minimum Performance Requirements for HSDPA UE categories 7 and 8** | 650d | 2003-09-19 A | 2006-03-16 | 99% | 0d | 2004-09-15 | 2005-06-15 | 195d? | 0d |  |  | R4 | 10400h | 5980h |  | RInImp-HSPerf-10code | Rel-6 |  | MCC_RAN | TSG | Jussi Numminen, Nokia | jussi.numminen@nokia.com |  |
| 13 | 7.1.1.1 | Testing of Improved Minimum Performance for HSDPA | 650d | 2003-09-19 A | 2006-03-16 A | 100% |  | 2004-09-15 | 2005-06-15 | 195d? |  | finish no earlier than 2006-03-16 |  | R5 | 5200h | 5200h |  | RInImp-HSPerf-10Code_Test | Rel-6 | 19/9/2003 | Stoyan Baev | TSG | Carolyn Taylor, Motorola | carolyn.taylor@motorola.com |  |
| 14 | 7.1.2 | **Performance Requirements of Receive Diversity for HSDPA** | 650d | 2003-09-19 A | 2006-03-16 | 99% | 0d | 2003-12-15 | 2005-03-15 | 326d | 0d |  |  | R4 | 10400h | 7808h |  | RInImp-HSPerf-RxDiv | Rel-6 |  | MCC RAN | TSG | Takehiro Nakamura (NTT DoCoMo) | takehiro@wsp.yrp.nttdocomo.co.jp |  |
| 15 | 7.1.2.1 | Testing of Performance of Receiver diversity for HSDPA | 650d | 2003-09-19 A | 2006-03-16 A | 100% |  | 2004-09-15 | 2005-06-15 | 195d? |  | finish no earlier than 2006-03-16 |  | R5 | 5200h | 5200h |  | RInImp-HSPerf-RxDiv_Test | Rel-6 | 19/9/2003 | Stoyan Baev | TSG | Carolyn Taylor, Motorola | carolyn.taylor@motorola.com |  |
| 16 | 8 | **FDD Enhanced Uplink** | 461d | 2005-06-03 A | 2007-03-09 | 60% | 184.4d | 2004-03-15 | 2005-06-15 | 327d | 0d |  |  | RP | 7376h | 2212.8h | Feat | EDCH | Rel-6 |  | Cesar | TSG | Joakim Bergström (Ericsson) |  | Active |
| 17 | 8.1 | Conformance Test Aspects – FDD Enhanced Uplink | 461d | 2005-06-03 A | 2007-03-09 | 60% | 184.4d | 2004-03-15 | 2005-06-15 | 327d | 0d | finish no earlier than 2007-03-09 | 2006-06-02 | R5 | 3688h | 2212.8h | BB | EDCH_Test | Rel-6 | Fri 03/06/05 | Stoyan Baev | TSG | Leif Mattisson (Ericsson) | Leif.Mattisson@ERICSSON.COM | Active |
| 18 | 34 | **Network Sharing** | 261d | 2005-03-11 A | 2006-03-10 A | 100% |  | 2003-01-20 | 2004-12-15 | 498d? |  |  |  | S1 | 6264h | 6264h |  | NTShar | Rel-6 |  | Michael | TSG |  |  |  |
| 19 | 9.1 | **Enhancement of the support of network sharing in the UTRAN** | 261d | 2005-03-11 A | 2006-03-10 A | 100% |  | 2003-09-19 | 2004-12-15 | 324d |  |  |  | R2 | 4176h | 4176h | BB | NTShar-UTRANEnh | Rel-6 |  | MCC_RAN | TSG | Anders Dahlén, TeliaSonera | Anders.Dahlen@TeliaSonera.com | Active |
| 20 | 16.5.1 | Conformance Test Aspects – Network Sharing | 261d | 2005-03-11 A | 2006-03-10 A | 100% |  | 2000-08-28 | 2003-06-13 | 730d |  | finish no earlier than 2006-03-10 | 2006-03-10 | R5 | 2088h | 2088h |  | NTShar-UTRANEnh_Test | Rel-6 | Fri 11/03/05 | Stoyan Baev |  | Niklas Wirén, TeliaSonera | Niklas.Wiren@TeliaSonera.com |  |
| 21 | 61 | **Small Technical Enhancements and Improvements for Rel4** | 2086d? | 2000-01-03 A | 2007-12-31 | 55% | 938.7d? | 2000-01-03 | 2001-03-30 | 325d | 262d |  |  | Generic | 6592h | 4412.8h | 1993 | TEI4 | Rel-4 |  |  | TSG |  |  |  |
| 22 | 10.1 | Small Technical Enhancements and Improvements for Rel-4 Conformance Testing | 412d? | 2000-01-03 A | 2007-12-31 | 55% | 185.4d? |  |  |  | 262d | finish no earlier than 2007-12-31 |  | R5 | 3296h | 1812.8h |  | TEI4_Test | Rel-4 |  | Stoyan Baev |  |  |  |  |
| 23 | 79 | **Rel-5 RAN improvements** | 321d | 2005-09-09 A | 2006-12-01 | 10% | 288.9d | 2001-03-16 | 2002-09-03 | 383d | 0d |  |  | RP | 7704h | 770.4h |  | RANimp | Rel-5 |  | Cesar | TSG |  |  |  |
| 24 | 79.7 | **RAB support enhancement for Rel-5** | 321d | 2005-09-09 A | 2006-12-01 | 10% | 288.9d | 2001-04-02 | 2002-06-28 | 325d | 0d |  |  | R2 | 5136h | 513.6h |  | RANimp-RABSE5 | Rel-5 |  |  | TSG | Juha Mikola, Nokia |  |  |
| 25 | 16.5.1 | Testing of ROHC performance | 321d | 2005-09-09 A | 2006-12-01 | 10% | 288.9d | 2000-08-28 | 2003-06-13 | 730d | 0d | finish no earlier than 2006-12-01 | 2006-06-02 | R5 | 2568h | 256.8h |  | RANimp-RABSE5_Test | Rel-5 | Fri 11/03/05 | Stoyan Baev |  | Jarkko Hellsten, Nokia | jarkko.hellsten@nokia.com |  |
| 26 | 81 | **Provisioning of IP-based multimedia services** | 451d | 2005-03-11 A | 2006-12-01 | 85% | 67.65d | 2000-01-03 | 2003-09-30 | 977d | 0d |  |  | S1 | 10256h | 8717.6h |  | IMS | NA |  | MichaelC/Alain | TSG | Mark Cataldo, Openwave |  |  |
| 27 | 81.1 | **Call control and roaming to support IMS in UMTS** | 451d | 2005-03-11 A | 2006-12-01 | 85% | 67.65d | 2000-01-03 | 2002-06-14 | 640d | 0d |  |  | S2 | 6928h | 5888.8h |  | IMS-CCR | Rel-5 |  |  | TSG | Liz Daniel, Lucent |  |  |
| 28 | 16.5.1 | Conformance Test Aspects – IMS Call Control | 451d | 2005-03-11 A | 2006-12-01 | 85% | 67.65d | 2000-08-28 | 2003-06-13 | 730d | 0d | finish no earlier than 2006-12-01 | 2006-06-02 | R5 | 3608h | 3066.8h |  | IMS-CCR_Test | Rel-5 | Fri 11/03/05 | Stoyan Baev |  | Jacob John, Motorola | Jacob.John@motorola.com |  |

Notes:
- 8: "Joker" WI, to be used for a Rel 99 CR not related to any feature and with very limited impact on the system
- 9: "Joker" WI, to be used for small modifications applicable to Rel 99 conformance testing
- 10: Status not tracked. Only Testing WIs tracked.
- 11: Status not tracked. Only Testing WIs tracked.
- 12: Status not tracked. Only Testing WIs tracked. / Text3: TS25.101
- 13: Text3: TS34.108, TS34.121, TS34.122, TS 34.123-1, TS 34.123-2, TS 34.123-3
- 14: Status not tracked. Only Testing WIs tracked. / Text3: TS25.101
- 15: Text3: TS34.108, TS34.121, TS34.122, TS 34.123-1, TS 34.123-2, TS 34.123-3
- 16: Status not tracked. Only Testing WIs tracked.
- 17: Text3: TS 34.108, 34.109, 34.121, 34.123-1, 34.123-2, 34.123-3
- 18: Status not tracked. Only Testing WIs tracked.
- 19: Status not tracked. Only Testing WIs tracked. / Text3: TS25.401, TS25.413, TS25.331, TS25.304
- 20: Text3: TS 34.108, 34.123-1, 34.123-2, 34.123-3
- 21: "Joker" WI, to be used for a Rel 4 CR not related to any feature and with very limited impact on the system
- 22: "Joker" WI, to be used for small modifications applicable to Rel 4 conformance testing
- 23: Status not tracked. Only Testing WIs tracked.
- 24: Status not tracked. Only Testing WIs tracked.
- 25: Text3: TS 34.108, 34.123-1, 34.123-2, 34.123-3
- 26: Status not tracked. Only Testing WIs tracked.
- 27: Status not tracked. Only Testing WIs tracked.
- 28: Text3: TS 34.108, TS34.229-1, TS34.229-2, TS34.229-3

| ID | WBS | Task | Duration | Start | Finish | Complete | Remaining | Baseline start | Baseline finish | Baseline duration | Total slack | Constraint | Deadline | Resources | Work | Actual work | Text1 | Text6 | Text8 | Text4 | Text5 | Text7 | Text9 | Text11 | Text10 |
| --- | --- | --- | --- | --- | --- | --- | --- | --- | --- | --- | --- | --- | --- | --- | --- | --- | --- | --- | --- | --- | --- | --- | --- | --- | --- |
| 29 | 13 | **Rel-7 Improvements of the Radio Interface** | 276d? | 2005-11-11 A | 2006-12-01 | 99% | 0d? | 2004-09-15 | 2006-06-15 | 456d? | 0d |  |  | RP | 5872h | 4832h | RInImp | Rel-7 | Cesar |  |  |  |  |  |  |
| 30 | 13.1 | UMTS 2.6 GHz | 121d? | 2005-11-11 A | 2006-06-02 A | 100% |  | 2004-09-15 | 2005-06-14 | 195d? |  |  |  | R4 | 968h | 968h | RInImp-UMTS2600 | Rel-7 | Cesar | Jussi Numminen, Nokia | jussi.numminen@nokia.com | TSG |  |  |  |
| 31 | 13.2 | UMTS 900 MHz | 146d? | 2005-11-11 A | 2006-06-02 A | 100% |  | 2004-12-15 | 2005-12-15 | 261d? |  |  |  | R4 | 1168h | 1168h | RInImp-UMTS900 | Rel-7 | MCC_RAN | Yannick Li (Nortel) | yli@nortelnetworks.com | TSG |  |  |  |
| 32 | 13.3 | Improved Performance Requirements for HSDPA UE based on Rx Diversity (type 1) & LMMSE equalizer (type 2) | 191d? | 2006-03-10 A | 2006-12-01 A | 100% |  |  |  |  |  |  |  | R4 | 1528h | 1528h | RInImp-HSPerf-Type3 | Rel-7 | MCC_RAN | Marc Grant | marc.grant@cingular.com |  |  |  |  |
| 33 | 16 | **IMS Phase 2** | 261d? | 2006-03-10 | 2007-03-09 |  |  | 2000-08-28 | 2009-11-05 | 2399d? | 473d |  |  | S1 | 2088h |  | IMS2 | Rel-6 | Sang-Ui |  |  | TSG |  |  |  |
| 34 | 14.1 | Conformance Test Aspects – IMS Call Control Rel-6 enhancements | 261d? | 2006-03-10 | 2007-03-09 |  |  |  |  |  | 473d | finish no earlier than 2007-03-09 |  | R5 | 2088h |  | IMS2_CCR_Test | Rel-6 | Stoyan Baev | Jacob John, Motorola, Leif Mattisson, Ericsson | Jacob.John@motorola.com, Leif.Mattisson@ERICSSON.COM |  |  |  |  |
| 35 | 8 | **Rel-6 Improvements of Radio Interface** | 191d? | 2006-03-10 A | 2006-12-01 | 99% | 0d? | 2000-08-14 | 2005-06-15 | 1262d? | 0d |  |  | RP | 4584h | 1544h | RInImp | Rel-6 | Cesar |  |  | TSG |  |  |  |
| 36 | 15.1 | **UMTS 1.7/2.1 GHz** | 191d? | 2006-03-10 A | 2006-12-01 | 99% | 0d? | 2003-03-14 | 2004-03-12 | 261d | 0d |  |  | R4 | 3056h | 1536h | RInImp-UMTS1721 | Rel-6 | MCC RAN | Jussi Numminen, Nokia | jussi.numminen@NOKIA.COM | TSG | BB | Active |  |
| 37 | 15.1.1 | Conformance Test Aspects –UMTS 1.7/2.1 GHz Band | 191d? | 2006-03-10 A | 2006-12-01 A | 100% |  |  |  |  |  | finish no earlier than 2006-12-01 |  | R5 | 1528h | 1528h | RInImp-UMTS1721_Test | Rel-6 | Stoyan Baev | Carolyn Taylor, Motorola | carolyn.taylor@motorola.com |  |  |  |  |
| 38 | 28 | **Multimedia Broadcast and Multicast Service** | 2006d? | 2000-01-03 A | 2007-09-10 | 54% | 927.28d? | 2001-05-11 | 2005-09-15 | 1134d | 342d |  |  | S1 | 40952.8h | 25425.1h | MBMS | Rel-6 | Michael |  |  | TSG |  |  |  |
| 39 | 28.3 | **Introduction of MBMS in RAN** | 1875d | 2000-01-03 A | 2007-03-09 A | 100% |  | 2002-01-01 | 2005-09-15 | 967d |  |  |  | R2 | 18608h | 18608h | MBMS-RAN | Rel-6 | MCC_RAN | Juho Pirskanen , Nokia | juho.pirskanen@nokia.com | TSG | 2481 |  |  |
| 40 | 16.1.1 | Introduction of MBMS in RAN (physical & upper layers, access network interfaces) | 771d | 2002-01-01 A | 2004-12-14 A | 100% |  | 2002-01-01 | 2004-12-14 | 771d |  | finish no earlier than 2004-12-14 |  | R2 | 6168h | 6168h | MBMS-RAN | Rel-6 | MCC_RAN | Juho Pirskanen , Nokia | juho.pirskanen@nokia.com | TSG |  |  |  |
| 41 | 16.1.2 | UE Performance Requirements for MBMS | 201d | 2000-01-03 A | 2007-03-09 A | 100% |  | 2004-09-15 | 2005-09-15 | 261d |  |  |  | R4 | 1608h | 1608h | MBMS-RAN-RF | Rel-6 | MCC_RAN | Torgny Palenius, Ericsson | Torgny.Palenius@ericsson.com | TSG |  |  |  |
| 42 | 16.2 | **MBMS UE Conformance Testing** | 392d? | 2006-03-10 A | 2007-09-10 | 7% | 362.78d? |  |  |  | 342d |  |  | R5 | 10743.2h | 578.4h | MBMS-UEConTest | Rel-6 | Stoyan Baev | RAN5 |  |  |  |  |  |
| 43 | 16.5.1 | RF/RRM Conformance Test Aspects – MBMS (FDD) | 201d | 2006-06-02 A | 2007-03-09 | 10% | 180.9d | 2000-08-28 | 2003-06-13 | 730d | 0d | finish no earlier than 2007-03-09 | 2006-06-02 | R5 | 1608h | 160.8h | MBMS-RAN-RF_Test | Rel-6 | Stoyan Baev | Leif Mattisson, Ericsson | leif.mattisson@ericsson.com |  |  |  | Fri 11/03/05 |
| 44 | 16.2.2 | Conformance Test Aspects - MBMS for 3.84 Mcps and 7.68 Mcps TDD | 254d? | 2006-09-20 | 2007-09-10 |  |  |  |  |  | 342d | finish no earlier than 2007-09-10 |  | R5 | 2032h |  | MBMS-UEConTest_TDH | Rel-6 | Stoyan Baev | Timothy Speight, IPWireless | tspeight@ipwireless.com |  |  |  |  |
| 45 | 16.2.3 | Signalling Conformance Test Aspects – MBMS for LCR TDD | 254d? | 2006-09-20 | 2007-09-10 |  |  |  |  |  | 342d | finish no earlier than 2007-09-10 |  | R5 | 2032h |  | MBMS-UEConTest_TDL | Rel-6 | Stoyan Baev | Zhao Jian, DATANG MOBILE | zhaojian@datangmobile.cn |  |  |  |  |
| 46 | 16.2.4 | Conformance Test Aspects – MBMS | 261d? | 2006-03-10 A | 2007-03-09 | 20% | 208.8d? |  |  |  | 473d | finish no earlier than 2007-03-09 |  | R5 | 2088h | 417.6h | MBMS_Test | Rel-6 | Stoyan Baev | Shubhang Vora, Qualcomm Europe S.A.R.L. | svora@qualcomm.com |  |  |  |  |
| 47 | 17 | **Small Technical Enhancements and Improvements for Rel6** | 412d? | 2006-06-02 A | 2007-12-31 | 10% | 370.8d? |  |  |  | 262d |  |  | Generic | 6592h | 659.2h | TEI6 | Rel-6 |  |  |  |  |  |  |  |
| 48 | 17.1 | Small Technical Enhancements and Improvements for Rel-6 Conformance Testing | 412d? | 2006-06-02 A | 2007-12-31 | 10% | 370.8d? |  |  |  | 262d | start no earlier than 2006-06-02 |  | R5 | 3296h | 329.6h | TEI6_Test | Rel-6 | Stoyan Baev |  |  |  |  |  |  |
| 49 | 77 | **High Speed Downlink Packet Access** | 906d? | 2003-09-19 A | 2007-03-09 | 91% | 79.05d? | 2001-04-02 | 2003-03-14 | 510d | 473d |  |  | R2 | 15624h | 14260.8h | HSDPA | Rel-5 | Cesar | Ravi Kuchibhotla, Motorola |  | TSG | 2476 |  |  |
| 50 | 18.1 | Conformance Testing of HSDPA | 786d | 2003-09-19 A | 2006-09-22 A | 100% |  | 2004-09-15 | 2005-06-15 | 195d? |  | finish no earlier than 2006-09-22 |  | R5 | 6288h | 6288h | HSDPA_Test | Rel-5 | Stoyan Baev | Carolyn Taylor, Motorola | carolyn.taylor@motorola.com | TSG |  |  | 19/9/2003 |
| 51 | 18.2 | Conformance Testing of HCR TDD HSDPA | 261d? | 2006-03-10 A | 2007-03-09 | 65% | 91.35d? |  |  |  | 473d | finish no earlier than 2007-03-09 |  | R5 | 2088h | 1357.2h | HSDPA_HCRTDD_Test | Rel-5 | Stoyan Baev | Derek Richards,IPWireless | drichards@ipwireless.com |  |  |  |  |
| 52 | 104 | **Small Technical Enhancements and Improvements for Rel5** | 2086d? | 2000-01-03 A | 2007-12-31 | 70% | 615.5d? | 2000-12-25 | 2002-03-22 | 325d | 262d |  |  | Generic | 29912h | 15755.2h | TEI5 | Rel-5 |  |  |  | TSG | 1993 |  |  |
| 53 | 19.1 | Small Technical Enhancements and Improvements for Rel-5 Conformance Testing | 2086d? | 2000-01-03 A | 2007-12-31 | 55% | 938.7d? |  |  |  | 262d |  |  | R5 | 16688h | 9178.4h | TEI5_Test | Rel-5 | Stoyan Baev |  |  |  |  |  |  |
| 54 | 19.2 | UE Antenna Performance Evaluation Method and Requirements | 1935d? | 2000-01-03 A | 2007-06-01 | 91% | 182d? | 2004-12-15 | 2006-06-15 | 392d | 413d |  |  | R4 | 1464h | 8h | RInImp-UEAnt | Rel-7 | MCC_RAN | Christian Bergljung (TeliaSonera) | Christian.Bergljung@TeliaSonera.com | TSG |  |  |  |

Notes:
- 29: Status not tracked. Only Testing WIs tracked.
- 30: Status not tracked. Only Testing WIs tracked. / Text3: TS25.101, TS25.104, TS25.133, TS25.141, TS25.331, TS25.942, TS25.306, TS25.307, TS34.121
- 31: Status not tracked. Only Testing WIs tracked. / Text3: 25.101, 25.104, 25.113, 25.133, 25.141, 25.331, 25.942, 25.306, 25.307, 34.121
- 32: Status not tracked. Only Testing WIs tracked. / Text3: 25.101
- 33: Status not tracked. Only Testing WIs tracked. / Text3: 23.228
- 34: Text3: 34.229-1, 34.229-2, 34.229-3, 34.108
- 35: Status not tracked. Only Testing WIs tracked.
- 36: Status not tracked. Only Testing WIs tracked. / Text3: TS25.101, 25.104, 25.133, 25.141, 25.307, 25.331
- 37: Text3: TS34.121, TS34.108
- 38: Title renamed at SA#13
- 39: Text3: TS 25.346, TS 25.304, 25.321, 25.322, 25.323, 25.331
- 40: Was "Introduction of MBMS in RAN" before RP#25. Created w/o WIDS after RAN approved the WT for RF aspects.Take WIDS from the parent BB / Text3: TS 25.346, TS 25.304, 25.321, 25.322, 25.323
- 41: Approved at RP#25 as RP-040370 / Text3: TS25.101, TS25.133
- 42: BB place holder for a number of RAN5 Tasks / Text3: TS 34.108, TS 34.109, TS 34.121-1, TS 34.121-2, TS 34.122, TS 34.123-1, TS 34.123-2, TS 34.123-3
- 43: TS 34.109 is under RAN2; RAN5 need to identify possible new requirements on UE test loop functionality to enable testing / Text3: TS 34.108, TS 34.109, TS 34.121-1, TS 34.121-2
- 44: Text3: TS 34.108, TS 34.122, TS 34.123-1, TS 34.123-2, TS 34.123-3
- 45: Text3: TS 34.108, TS 34.123-1, TS 34.123-2, TS 34.123-3
- 46: Text3: TS34.108, TS34.123-1, TS34.123-2, TS34.123-3
- 47: "Joker" WI, to be used for a Rel 6 CR not related to any feature and with very limited impact on the system
- 48: "Joker" WI, to be used for small modifications applicable to Rel 4 conformance testing / Text3: TS34.108, TS34.121-1, TS34.121-2, TS34.122, TS 34.123-1, TS 34.123-2, TS 34.123-3
- 49: Status not tracked. Only Testing WIs tracked.
- 50: Text3: TS34.108, TS34.121, TS34.122, TS 34.123-1, TS 34.123-2, TS 34.123-3
- 51: Text3: TS34.108, TS34.122, TS 34.123-1, TS 34.123-2, TS 34.123-3
- 52: "Joker" WI, to be used for a Rel 5 CR not related to any feature and with very limited impact on the system
- 53: "Joker" WI, to be used for small modifications applicable to Rel 5 conformance testing / Text3: TS 34.108, TS 34.109, TS 34.121-1, TS 34.121-2, TS 34.122, TS 34.123-1, TS 34.123-2, TS 34.123-3, Ts 34.171, TS 34.229-1, TS 34.229-2, TS 34.229-3
- 54: Status not tracked. Only Testing WIs tracked. / Text3: TS25.101

| ID | WBS | Task | Duration | Start | Finish | Complete | Remaining | Baseline start | Baseline finish | Baseline duration | Total slack | Constraint | Deadline | Resources | Work | Actual work | Text1 | Text4 | Text6 | Text8 | Text10 | Text5 | Text7 |
| --- | --- | --- | --- | --- | --- | --- | --- | --- | --- | --- | --- | --- | --- | --- | --- | --- | --- | --- | --- | --- | --- | --- | --- |
| 55 | 19.3 | **Rel-7 Improvements of the Radio Interface UE Confromance Testing** | 406d? | 2005-11-11 A | 2007-06-01 | 62% | 153.28d? |  |  |  | 413d |  |  | R5 | 8464h | 3968.8h | RInImp-UEConTest | RAN5 | Rel-7 | Stoyan Baev |  |  |  |
| 56 | 16.5.1 | UE conformance testing for UMTS 2600 MHz | 146d | 2005-11-11 A | 2006-06-02 A | 100% |  | 2000-08-28 | 2003-06-13 | 730d |  | finish no earlier than 2006-06-02 | 2006-06-02 | R5 | 1168h | 1168h | RInImp-UMTS2600_Test | Aleksi Heino, Nokia | Rel-7 | Stoyan Baev | Fri 7/11/05 |  |  |
| 57 | 16.5.1 | UE Conformance Test for UMTS in 900 MHz band (band VIII) | 146d | 2005-11-11 A | 2006-06-02 A | 100% |  | 2000-08-28 | 2003-06-13 | 730d |  | finish no earlier than 2006-06-02 | 2006-06-02 | R5 | 1168h | 1168h | RInImp-UMTS900_Test | Hany El-Saidany, Qualcomm Europe S.A.R.L. | Rel-7 | Stoyan Baev | Fri 11/03/05 | hanye@qualcomm.com |  |
| 58 | 19.3.3 | Conformance Test Aspects – Improved Performance of HSDPA Receiver type 3 | 191d? | 2006-03-10 A | 2006-12-01 A | 100% |  |  |  |  |  | finish no earlier than 2006-12-01 |  | R5 | 1528h | 1528h | RInImp-HSPerf-Type3_Test | Carolyn Taylor, Motorola | Rel-7 | Stoyan Baev |  | carolyn.taylor@motorola.com |  |
| 59 | 19.3.4 | UE antenna over the air conformance testing | 183d? | 2006-09-20 | 2007-06-01 |  |  |  |  |  | 413d | finish no earlier than 2007-06-01 |  | R5 | 1464h |  | RInImp-UEAnt_Test | Aleksi Heino, Nokia | Rel-7 | Stoyan Baev |  | Aleksi.Heino@nokia.com |  |
| 60 | 19.3.5 | UE conformance testing for FDD Inter-Band Operation | 131d? | 2006-06-02 A | 2006-12-01 | 10% | 117.9d? |  |  |  | 543d | finish no earlier than 2006-12-01 |  | R5 | 1048h | 104.8h | RInImp-InterBand_Test | Andreas Wilde, NEC; Jacob John, Motorola | Rel-7 | Stoyan Baev |  | Jacob.John@motorola.com |  |
| 61 | 20 | **7.68Mcps TDD option** | 779d? | 2004-09-15 A | 2007-09-10 | 82% | 137.05d? | 2004-09-15 | 2006-06-15 | 457d | 342d |  |  | RP | 24432h | 16376.2h | VHCRTDD | Martin Beale, IPWireless | Rel-7 | Cesar |  | mbeale@ipwireless.com | TSG |
| 62 | 20.1 | VHCRTDD: Stage 2 | 391d | 2004-09-15 A | 2006-03-15 A | 100% |  | 2004-09-15 | 2006-03-15 | 391d |  | finish no earlier than 2006-03-15 |  | R1 | 3128h | 3128h | VHCRTDD-Stage2 | Martin Beale, IPWireless | Rel-7 | MCC_RAN |  | mbeale@ipwireless.com | TSG |
| 63 | 20.2 | VHCRTDD: Physical Layer | 391d | 2004-09-15 A | 2006-03-15 A | 100% |  | 2004-09-15 | 2006-03-15 | 391d |  | finish no earlier than 2006-03-15 |  | R1 | 3128h | 3128h | VHCRTDD-Phys | Martin Beale, IPWireless | Rel-7 | MCC_RAN |  | mbeale@ipwireless.com | TSG |
| 64 | 20.3 | VHCRTDD: Layer 2 and layer 3 protocol aspects | 391d | 2004-09-15 A | 2006-03-15 A | 100% |  | 2004-09-15 | 2006-03-15 | 391d |  | finish no earlier than 2006-03-15 |  | R2 | 3128h | 3128h | VHCRTDD-L23 | Derek Richards, IPWireless | Rel-7 | MCC_RAN |  | drichards@ipwireless.com | TSG |
| 65 | 20.4 | VHCRTDD: UTRAN Iub/Iur Protocol Aspects | 391d | 2004-09-15 A | 2006-03-15 A | 100% |  | 2004-09-15 | 2006-03-15 | 391d |  | finish no earlier than 2006-03-15 |  | R3 | 3128h | 3128h | VHCRTDD-IurIub | Peter Legg, IPWireless | Rel-7 | MCC_RAN |  | plegg@ipwireless.com | TSG |
| 66 | 20.5 | VHCRTDD: RF Radio Transmission/ Reception, System Performance Requirements and Conformance Testing | 457d | 2004-09-15 A | 2006-06-15 | 68% | 146.24d | 2004-09-15 | 2006-06-15 | 457d | 664d | finish no earlier than 2006-06-15 |  | R4 | 3656h | 2486.08h | VHCRTDD-RF | Shin Horng Wong | Rel-7 | MCC_RAN |  | shwong@ipwireless.com | TSG |
| 67 | 20.6 | Conformance Test Aspects - 7.68 Mcps TDD | 254d? | 2006-09-20 | 2007-09-10 |  |  |  |  |  | 342d | finish no earlier than 2007-09-10 |  | R5 | 2032h |  | VHCRTDD-UEConTest | Timothy Speight,IPWireless | Rel-7 | Stoyan Baev |  | tspeight@ipwireless.com |  |
| 68 | 21 | **Rel-7 RAN improvements** | 839d? | 2004-12-15 A | 2008-03-03 | 55% | 377.41d? | 2004-12-15 | 2006-12-15 | 523d | 217d |  |  | RP | 28544h | 11035.5h | RANimp |  | Rel-7 | MCC_RAN |  |  | TSG |
| 69 | 21.1 | Optimisation of channelisation code utilisation for 1.28 Mcps TDD | 458d | 2004-12-15 A | 2006-09-15 | 85% | 68.7d | 2004-12-15 | 2006-06-15 | 392d | 598d | finish no earlier than 2006-09-15 |  | R1 | 3664h | 3114.4h | RANimp-RABSE-CodOptLCRTDD | Ka Leong Lo | Rel-7 | MCC_RAN |  | kaleong.lo@utstar.com | TSG |
| 70 | 21.2 | Delay optimisation for procedures applicable to CS and PS Connections | 394d | 2005-03-15 A | 2006-09-15 | 40% | 236.4d | 2005-03-15 | 2006-09-15 | 394d | 598d | finish no earlier than 2006-09-15 |  | R2 | 3152h | 1260.8h | RANimp-DelayOpt | Juho Pirskanen | Rel-7 | MCC_RAN |  | juho.pirskanen@nokia.com | TSG |
| 71 | 21.3 | UE Performance Requirements for MBMS (TDD) | 328d | 2005-03-15 A | 2006-06-15 | 99% | 3.28d | 2005-03-15 | 2006-06-15 | 328d | 664d | finish no earlier than 2006-06-15 |  | R4 | 2624h | 2597.77h | MBMS-RAN-RF-TDD | Shin Horng Wong | Rel-7 | MCC_RAN |  | shwong@ipwireless.com | TSG |
| 72 | 21.4 | Continuous connectivity for packet data users | 460d | 2005-03-14 A | 2006-12-15 | 60% | 184d | 2005-03-14 | 2005-09-15 | 134d | 533d | finish no earlier than 2006-12-15 |  | R1 | 3680h | 2208h | RANimp-CPC | Joern Krause | Rel-7 | MCC_RAN |  | Joern.Krause@siemens.com | TSG |
| 73 | 21.5 | Extended WCDMA Cell Range | 133d | 2006-03-15 A | 2006-09-15 | 72% | 37.24d | 2006-03-15 | 2006-09-15 | 133d | 598d | finish no earlier than 2006-09-15 |  | R3 | 1064h | 766.08h | RANimp-ExtCell | Ericsson | Rel-7 | MCC_RAN |  |  |  |
| 74 | 21.6 | 7.68 Mcps TDD Enhanced Uplink | 198d | 2006-03-15 A | 2006-12-15 | 25% | 148.5d | 2006-03-15 | 2006-12-15 | 198d | 533d | finish no earlier than 2006-12-15 |  | R1 | 1584h | 396h | RANimp-VHCRTDD-EDCH | Nicholas Anderson | Rel-7 | MCC_RAN |  | nanderson@ipwireless.com |  |
| 75 | 21.7 | **UE Conformance Testing for Rel-7 RAN improvements** | 379d? | 2006-09-20 | 2008-03-03 |  |  |  |  |  | 217d |  |  | R5 | 6064h |  | RANimp-UEConTest | RAN5 | Rel-7 | Stoyan Baev |  |  |  |
| 76 | 21.7.1 | Conformance Test Aspects - 3.84 Mcps and 7.68 Mcps TDD Enhanced Uplink | 379d? | 2006-09-20 | 2008-03-03 |  |  |  |  |  | 217d | finish no earlier than 2008-03-03 |  | R5 | 3032h |  | RANimp-UEConTest_EDCHTDH | Timothy Speight,IPWireless | Rel-7 | Stoyan Baev |  | tspeight@ipwireless.com |  |

Notes:
- 55: BB place holder for a number of RAN5 Tasks
- 56: Text3: TS 34.108, 34.121
- 57: Text3: TS 34.108, 34.121
- 58: Text3: TS34.121, TS 34.108
- 59: Text3: TS34.114
- 60: Text3: TS34.108, TS34.123-1, TS34.123-2, TS34.123-3
- 61: Approved at RP#25 as RP-040365
- 62: Text3: TS25.202
- 63: Text3: TS25.221, TS25.222, TS25.223, TS25.224,TS25.225
- 64: Text3: TS25.301, TS25.302, TS25.305, TS25.306, TS25.321, TS25.331
- 65: Text3: TS25.401, TS25.420, TS25.423, TS25.425, TS25.427, TS25.430, TS25.433, TS25.435
- 66: Text3: TS25.102, TS25.105, TS25.123, TS25.133, TS25.142
- 67: Text3: TS34.108, TS34.122, TS 34.123-1, TS 34.123-2, TS 34.123-3
- 68: Generic feature
- 70: Text3: TS25.321, TS25.322, TS25.331
- 71: Text3: TS25.102, TS25.123
- 73: Text3: 25.133, 25.423, 25.425, 25.433, 25.435, 25.453, 25.331
- 74: Text3: 25.201, 25.202, 25.221, 25.222, 25.223, 25.224, 25.225, 25.331, 23.321, 25.306, 25.302, 25.401, 25.420, 25.423, 25.427, 25.433, 25.102, 25.105, 25.142
- 76: Covers also requirements in Feature EDCHTDD / Text3: TS34.108, TS34.122, TS 34.123-1, TS 34.123-2, TS 34.123-3
